# modular PLASC

How a schedule from MS Project changed from version to version. A marks actual dates.

## Version 1 (saved 2011-11-02)

| ID | WBS | Task | Duration | Start | Finish | Predecessors | Total float | Constraint |
| --- | --- | --- | --- | --- | --- | --- | --- | --- |
| 2 |  | NDC 2012 Guidance Notes Released | 1d | 2012-04-09 | 2012-04-09 |  | 192d | start no earlier than 2012-04-09 |
| 4 |  | Attendance Secondary 2012 Guidance Notes Released | 1d | 2012-04-25 | 2012-04-25 |  | 180d | start no earlier than 2012-04-25 |
| 6 | 3 | **WED 2012 on DEWi** | 22d | 2012-04-16 | 2012-05-15 |  | 252d |  |
| 7 |  | WED 2012 DEWi development | 10d | 2012-04-16 | 2012-04-27 |  | 252d | start no earlier than 2012-04-16 |
| 8 |  | WED 2012 DEWi UAT | 5d | 2012-04-30 | 2012-05-04 | 7 | 252d | start no earlier than 2009-03-30 |
| 9 |  | WED 2012 DEWi rework | 3d | 2012-05-07 | 2012-05-09 | 8 | 252d | start no earlier than 2009-04-06 |
| 10 |  | WED 2012 Release to test DEWi site | 1d | 2012-05-10 | 2012-05-10 | 9 | 252d |  |
| 11 |  | WED 2012 DEWi UAT on test site | 2d | 2012-05-11 | 2012-05-14 | 10 | 252d |  |
| 12 |  | WED 2012 Release to live DEWi site | 1d | 2012-05-15 | 2012-05-15 | 11 | 252d | start no earlier than 2009-08-03 |
| 15 | 4 | **Spring SDF meetings** | 21d | 2012-02-16 | 2012-03-15 |  | 0d |  |
| 16 |  | Software Development Forum meeting | 1d | 2012-02-16 | 2012-02-16 |  | 0d | start no earlier than 2012-02-16 |
| 17 |  | Spec review period: PLASC, EOTAS & Attendance 2013 | 16d | 2012-02-17 | 2012-03-09 | 16 | 298d | finish no earlier than 2011-03-02 |
| 18 |  | Software Development Forum meeting | 1d | 2012-03-15 | 2012-03-15 | 17 | 295d | start no earlier than 2012-03-15 |
| 20 | 5 | **CBDS (standard) change cycle** | 1d | 2012-04-02 | 2012-04-02 |  | 283d |  |
| 21 |  | CBDS 1213 published | 1d | 2012-04-02 | 2012-04-02 |  | 283d | start no earlier than 2012-04-02 |
| 22 |  | Publish 1213 Learning Activity codeset (look-up) | 1d | 2012-04-02 | 2012-04-02 |  | 283d | start no earlier than 2012-04-02 |
| 23 |  | Publish 1213 Learning Activity Provider codeset (look-up) | 1d | 2012-04-02 | 2012-04-02 |  | 283d | start no earlier than 2012-04-02 |
| 24 | 6 | **Develop January PLASC and EOTAS 2013** | 102d | 2012-02-10 | 2012-07-02 |  | 218d |  |
| 25 | 6.1 | **Specification** | 21d | 2012-02-10 | 2012-03-09 |  | 299d |  |
| 26 |  | Draft specification release | 1d | 2012-02-10 | 2012-02-10 |  | 319d | start no earlier than 2012-02-10 |
| 27 |  | Supplier review period | 16d | 2012-02-13 | 2012-03-05 |  | 303d | start no earlier than 2012-02-13 |
| 28 |  | Version 1 specification release | 1d | 2012-03-09 | 2012-03-09 |  | 299d | start no earlier than 2012-03-09 |
| 29 | 6.2 | **xslt development** | 18d | 2012-06-04 | 2012-06-27 |  | 221d |  |
| 30 |  | Draft fileset release | 1d | 2012-06-04 | 2012-06-04 |  | 226d | start no earlier than 2012-06-04 |
| 31 |  | Supplier review period | 11d | 2012-06-05 | 2012-06-19 | 30 | 226d |  |
| 32 |  | Final fileset release | 1d | 2012-06-27 | 2012-06-27 | 31 | 221d | start no earlier than 2012-06-27 |
| 33 | 6.3 | **DEWi developments** | 1d | 2012-07-02 | 2012-07-02 |  | 218d |  |
| 34 |  | Release to supplier test DEWi sites for PLASC & EOTAS 2013 | 1d | 2012-07-02 | 2012-07-02 |  | 218d | start no earlier than 2012-07-02 |
| 36 | 7 | **January PLASC & EOTAS 2013 xslt and DEWi development** | 188d | 2012-04-16 | 2013-01-02 |  | 86d |  |
| 37 |  | Jan & EOTAS 2013 xslt & DEWi development | 25d | 2012-04-16 | 2012-05-18 |  | 229d | start no earlier than 2012-04-16 |
| 38 |  | Jan & EOTAS 2013 xslt UAT | 9d | 2012-05-22 | 2012-06-01 | 37 | 228d | start no earlier than 2012-05-22 |
| 39 |  | Jan & EOTAS 2013 xslt draft fileset release | 1d | 2012-06-04 | 2012-06-04 | 38 | 238d | start no earlier than 2012-06-04 |
| 40 |  | Jan & EOTAS 2013 DEWi UAT | 8d | 2012-06-04 | 2012-06-13 | 38 | 228d | start no earlier than 2012-06-04 |
| 41 |  | Jan & EOTAS 2013 xslt supplier review period | 11d | 2012-06-05 | 2012-06-19 |  | 227d | start no earlier than 2012-06-05 |
| 42 |  | Jan & EOTAS 2013 xslt rework | 3d | 2012-06-20 | 2012-06-22 |  | 217d | start no earlier than 2012-06-20 |
| 43 |  | Jan & EOTAS 2013 xslt rework UAT | 2d | 2012-06-25 | 2012-06-26 | 42 | 217d | start no earlier than 2008-12-11 |
| 44 |  | Jan & EOTAS 2013 DEWi rework | 3d | 2012-06-25 | 2012-06-27 | 40, 42 | 221d | start no earlier than 2012-06-14 |
| 45 |  | Jan & EOTAS 2013 xslt final fileset release | 1d | 2012-06-27 | 2012-06-27 | 43 | 221d | start no earlier than 2012-06-27 |
| 46 |  | Jan & EOTAS 2013 Release to test DEWi site | 1d | 2012-06-27 | 2012-06-27 | 43 | 217d | start no earlier than 2012-06-27 |
| 47 |  | Jan & EOTAS 2013 DEWi UAT on test site | 3d | 2012-06-28 | 2012-07-02 | 46 | 217d | start no earlier than 2009-07-08 |
| 48 |  | Jan & EOTAS 2013 Release to supplier test DEWi site | 1d | 2012-07-03 | 2012-07-03 | 47 | 217d | start no earlier than 2009-07-14 |
| 49 |  | Jan & EOTAS 2013 Release to live DEWi site | 1d | 2013-01-02 | 2013-01-02 | 47 | 86d | start no earlier than 2013-01-02 |
| 52 |  | Post-16 PLASC 2012 Guidance Notes Released | 1d | 2012-08-24 | 2012-08-24 |  | 179d | start no earlier than 2012-08-24 |
| 55 | 9 | **Develop Attendance 2013** | 167d | 2012-02-10 | 2012-10-01 |  | 153d |  |
| 56 | 9.1 | **Specification** | 21d | 2012-02-10 | 2012-03-09 |  | 299d |  |
| 57 |  | Draft specification release | 1d | 2012-02-10 | 2012-02-10 |  | 319d | start no earlier than 2012-02-10 |
| 58 |  | Supplier review period | 16d | 2012-02-13 | 2012-03-05 |  | 303d | start no earlier than 2012-02-13 |
| 59 |  | Version 1 specification release | 1d | 2012-03-09 | 2012-03-09 |  | 299d | start no earlier than 2012-03-09 |
| 60 | 9.2 | **xslt development** | 18d | 2012-09-03 | 2012-09-26 |  | 156d |  |
| 61 |  | Draft fileset release | 1d | 2012-09-03 | 2012-09-03 |  | 161d | start no earlier than 2012-09-03 |
| 62 |  | Supplier review period | 11d | 2012-09-04 | 2012-09-18 | 61 | 161d | start no earlier than 2010-09-07 |
| 63 |  | Final fileset release | 1d | 2012-09-26 | 2012-09-26 | 62 | 156d | start no earlier than 2012-09-26 |
| 64 | 9.3 | **DEWi developments** | 1d | 2012-10-01 | 2012-10-01 |  | 153d |  |
| 65 |  | Release to supplier test DEWi sites for Attendance & NDC 2013 | 1d | 2012-10-01 | 2012-10-01 |  | 153d | start no earlier than 2012-10-01 |
| 67 |  | Attendance Primary 2012 Guidance Notes Released | 1d | 2012-06-29 | 2012-06-29 |  | 219d | start no earlier than 2012-06-29 |
| 69 | 11 | **Summer Attendance & NDC 2013 xslt and DEWi development** | 199d | 2012-07-30 | 2013-05-02 |  | 0d |  |
| 70 |  | Summer 2013 xslt and DEWi development | 20d | 2012-07-30 | 2012-08-24 |  | 151d | start no earlier than 2012-07-30 |
| 71 |  | Summer 2013 xslt UAT | 5d | 2012-08-27 | 2012-08-31 | 70 | 151d | start no earlier than 2009-05-25 |
| 72 |  | Summer 2013 xslt draft fileset release | 1d | 2012-09-03 | 2012-09-03 | 71 | 151d | start no earlier than 2010-09-06 |
| 73 |  | Summer 2013 xslt supplier review period | 11d | 2012-09-04 | 2012-09-18 | 72 | 151d |  |
| 74 |  | Summer 2013 DEWi UAT | 5d | 2012-09-03 | 2012-09-07 | 71 | 163d |  |
| 75 |  | Summer 2013 xslt rework | 4d | 2012-09-19 | 2012-09-24 | 73 | 151d | finish no earlier than 2011-09-21 |
| 76 |  | Summer 2013 xslt rework UAT | 2d | 2012-09-25 | 2012-09-26 | 75 | 151d | start no earlier than 2008-12-11 |
| 77 |  | Summer 2013 DEWi rework | 5d | 2012-09-19 | 2012-09-25 | 73, 74 | 156d | start no earlier than 2012-09-13 |
| 78 |  | Summer 2013 Release to test DEWi site for NDC & Attendance collections 2013 | 1d | 2012-09-26 | 2012-09-26 | 77 | 156d | start no earlier than 2009-10-02 |
| 79 |  | Summer 2013 xslt final fileset release | 1d | 2012-09-27 | 2012-09-27 | 76 | 151d | start no earlier than 2012-09-26 |
| 80 |  | Summer 2013 DEWi UAT on test site | 3d | 2012-09-28 | 2012-10-02 | 79 | 151d |  |
| 81 |  | Summer 2013 Release to supplier test DEWi site for NDC & Attendance collections 2013 | 1d | 2012-10-03 | 2012-10-03 | 80 | 151d | start no earlier than 2011-10-03 |
| 82 |  | Summer 2013 Release to live DEWi site for NDC & Attendance collections 2013 | 1d | 2013-05-02 | 2013-05-02 | 80 | 0d | start no earlier than 2013-05-02 |
| 84 | 12 | **Summer SDF meeting** | 17d | 2012-06-07 | 2012-06-29 |  | 219d |  |

| ID | WBS | Task | Duration | Start | Finish | Predecessors | Total float | Constraint |
| --- | --- | --- | --- | --- | --- | --- | --- | --- |
| 85 |  | Software Development Forum meeting | 1d | 2012-06-07 | 2012-06-07 |  | 219d | start no earlier than 2012-06-07 |
| 86 |  | Spec review period | 16d | 2012-06-08 | 2012-06-29 | 85 | 219d | start no earlier than 2009-10-07 |
| 87 | 13 | **Develop NDC 2013** | 87d | 2012-06-01 | 2012-10-01 |  | 153d |  |
| 88 | 13.1 | **Specification** | 19d | 2012-06-01 | 2012-06-27 |  | 221d |  |
| 89 |  | Draft specification release | 1d | 2012-06-01 | 2012-06-01 |  | 222d | start no earlier than 2012-06-01 |
| 90 |  | Supplier review period | 16d | 2012-06-04 | 2012-06-25 | 89 | 222d | start no earlier than 2011-06-08 |
| 91 |  | Version 1 specification release | 1d | 2012-06-27 | 2012-06-27 | 90 | 221d | start no earlier than 2012-06-27 |
| 92 | 13.2 | **xslt development** | 19d | 2012-09-03 | 2012-09-27 |  | 155d |  |
| 93 |  | Draft fileset release | 1d | 2012-09-03 | 2012-09-03 |  | 161d | start no earlier than 2012-09-03 |
| 94 |  | Supplier review period | 11d | 2012-09-04 | 2012-09-18 | 93 | 161d | start no earlier than 2008-09-16 |
| 95 |  | Final fileset release | 1d | 2012-09-27 | 2012-09-27 | 94 | 155d | start no earlier than 2012-09-27 |
| 96 | 13.3 | **DEWi developments** | 1d | 2012-10-01 | 2012-10-01 |  | 153d |  |
| 97 |  | Release to supplier test DEWi sites for Attendance & NDC 2013 | 1d | 2012-10-01 | 2012-10-01 |  | 153d | start no earlier than 2012-10-01 |
| 99 | 14 | **Autumn SDF meetings** | 21d | 2012-10-09 | 2012-11-06 |  | 127d |  |
| 100 |  | Software Development Forum meeting | 1d | 2012-10-09 | 2012-10-09 |  | 130d | start no earlier than 2012-10-09 |
| 101 |  | Spec review period | 16d | 2012-10-10 | 2012-10-31 | 100 | 130d | start no earlier than 2009-10-07 |
| 102 |  | Software Development Forum meeting | 1d | 2012-11-06 | 2012-11-06 | 101 | 127d | start no earlier than 2012-11-06 |
| 104 | 15 | **Develop Post-16 September PLASC 2013** | 136d | 2012-10-04 | 2013-04-11 |  | 15d |  |
| 105 | 15.1 | **Specification** | 21d | 2012-10-04 | 2012-11-01 |  | 130d |  |
| 106 |  | Draft specification release | 1d | 2012-10-04 | 2012-10-04 |  | 134d | start no earlier than 2012-10-04 |
| 107 |  | Supplier review period | 16d | 2012-10-05 | 2012-10-26 | 106 | 134d | start no earlier than 2011-10-12 |
| 108 |  | Version 1 specification release | 1d | 2012-11-01 | 2012-11-01 |  | 130d | start no earlier than 2012-11-01 |
| 109 | 15.2 | **xslt development** | 103d | 2012-11-20 | 2013-04-11 |  | 15d |  |
| 110 |  | Draft fileset release | 1d | 2012-11-20 | 2012-11-20 |  | 105d | start no earlier than 2012-11-20 |
| 111 |  | Supplier review period | 11d | 2012-11-21 | 2012-12-05 | 110 | 105d |  |
| 112 |  | Final fileset release | 1d | 2012-12-13 | 2012-12-13 | 111 | 100d | start no earlier than 2012-12-13 |
| 113 |  | Update of fileset release with 13/14 look-ups | 1d | 2013-04-11 | 2013-04-11 |  | 15d | start no earlier than 2013-04-11 |
| 114 | 15.3 | **DEWi developments** | 82d | 2012-12-13 | 2013-04-05 |  | 19d |  |
| 115 |  | Release to supplier test DEWi sites for Post-16 September PLASC 2013 | 1d | 2012-12-13 | 2012-12-13 |  | 100d | start no earlier than 2012-12-13 |
| 116 |  | Release update with look-ups to supplier test DEWi site Post-16 September PLASC 2013 | 1d | 2013-04-05 | 2013-04-05 |  | 19d | start no earlier than 2013-04-05 |
| 117 | 16 | **Post-16 Sept 2013 xslt and DEWi development** | 115d | 2012-11-01 | 2013-04-10 |  | 16d |  |
| 118 |  | Sept 2013 xslt and DEWi development | 10d | 2012-11-01 | 2012-11-14 |  | 92d | start no earlier than 2012-11-01 |
| 119 |  | Sept 2013 xslt UAT | 3d | 2012-11-15 | 2012-11-19 | 118 | 92d | start no earlier than 2009-11-16 |
| 120 |  | Sept 2013 xslt draft fileset release | 1d | 2012-11-20 | 2012-11-20 | 119 | 92d | start no earlier than 2009-11-23 |
| 121 |  | Sept 2013 xslt supplier review period | 11d | 2012-11-21 | 2012-12-05 | 120 | 92d |  |
| 122 |  | September 2013 DEWi UAT | 3d | 2012-11-20 | 2012-11-22 | 119 | 105d |  |
| 123 |  | Sept 2013 xslt rework | 3d | 2012-12-06 | 2012-12-10 | 121 | 92d |  |
| 124 |  | Sept 2013 xslt rework UAT | 2d | 2012-12-11 | 2012-12-12 | 123 | 92d |  |
| 125 |  | September 2013 DEWi rework | 5d | 2012-12-06 | 2012-12-12 | 121, 122 | 96d |  |
| 126 |  | September 2013 Release to test DEWi site | 1d | 2012-12-13 | 2012-12-13 | 125 | 96d |  |
| 127 |  | Sept 2013 xslt final fileset release | 1d | 2012-12-13 | 2012-12-13 | 124 | 92d | start no earlier than 2011-12-12 |
| 128 |  | September 2013 DEWi UAT on test site | 3d | 2012-12-14 | 2012-12-18 | 126 | 96d |  |
| 129 |  | September 2013 Release to supplier test DEWi site | 1d | 2012-12-19 | 2012-12-19 | 128 | 96d | start no earlier than 2009-12-21 |
| 130 |  | Sept 2013 xslt and DEWi inclusion of 13/14 look-ups | 4d | 2013-04-01 | 2013-04-04 | 127 | 16d | start no earlier than 2013-04-01 |
| 131 |  | Sept 2013 xslt and DEWi UAT on 13/14 look-ups update | 3d | 2013-04-05 | 2013-04-09 | 130 | 16d |  |
| 132 |  | Sept 2013 xslt update release | 1d | 2013-04-10 | 2013-04-10 | 131 | 16d | start no earlier than 2010-04-15 |
| 133 |  | September 2013 Release to live DEWi site | 1d | 2013-04-10 | 2013-04-10 | 131 | 16d | start no earlier than 2010-09-16 |
| 135 |  | Jan PLASC & EOTAS 2013 Guidance Notes Released | 1d | 2012-12-10 | 2012-12-10 |  | 103d | start no earlier than 2012-12-10 |

## Version 2 (saved 2012-12-07)

Last finish 2013-05-02 → 2014-05-02 (+365d).

Added:

| ID | Task | Duration | Start | Finish | Predecessors | Constraint | Resources |
| --- | --- | --- | --- | --- | --- | --- | --- |
| 14 | Review and update the ULN collection, also taking account of CTF changes | 1d? | 2013-04-16 | 2013-04-16 |  | start no earlier than 2013-04-16 | WG |
| 17 | CTF13 draft release to suppliers | 1d | 2013-02-01 | 2013-02-01 |  | start no earlier than 2013-02-01 | WG |
| 19 | A_COMP 2013 Review | 43d | 2013-02-01 | 2013-04-02 |  | start no earlier than 2013-02-01 | WG |
| 20 | CTF13 final release to suppliers | 1d | 2013-03-01 | 2013-03-01 |  | start no earlier than 2013-03-01 | WG |
| 30 | A_COMP published | 1d | 2013-04-02 | 2013-04-02 |  | start no earlier than 2013-04-02 | WG |
| 63 | Data removal - PLASC 2013 data | 1d | 2013-08-23 | 2013-08-23 |  | start no earlier than 2013-08-23 | WG |
| 65 | Fixed reports for NDC 2013 | 21d | 2013-08-27 | 2013-09-24 |  | start no earlier than 2013-08-27 | WG |
| 66 | Data removal - NDC 2013 data | 1d | 2013-09-25 | 2013-09-25 | 65 | start no earlier than 2009-09-30 | WG |
| 67 | Data removal - Attendance 2013 | 1d | 2013-10-25 | 2013-10-25 |  | start no earlier than 2013-10-25 | WG |
| 113 | DEWI user audit | 20d | 2013-09-03 | 2013-09-30 |  | start no earlier than 2013-09-03 | WG |
| 115 | s2s user audit | 20d | 2013-09-03 | 2013-09-30 |  | start no earlier than 2013-09-03 | WG |
| 156 | CTF14 consultation | 21d | 2013-12-03 | 2013-12-31 |  | start no earlier than 2013-12-03 | WG |
| 160 | Data Demons Released | 1d | 2013-12-10 | 2013-12-10 |  | start no earlier than 2013-12-10 | WG |
| 162 | Data removal - Post-16 September PLASC 2013 data | 1d | 2014-01-24 | 2014-01-24 |  | start no earlier than 2014-01-24 | WG |
| 164 | CTF14 draft release to suppliers | 20d | 2014-01-31 | 2014-02-27 |  | start no earlier than 2014-01-31 | WG |

Changed:

| ID | Task | Start | Finish | Duration | Total float | Predecessors | Other |
| --- | --- | --- | --- | --- | --- | --- | --- |
| 2 | NDC 2013 Reporting Arrangements Released | 2012-04-09 → 2013-04-09 (+365d) | 2012-04-09 → 2013-04-09 (+365d) |  | 192d → 278d |  | was named NDC 2012 Guidance Notes Released; constraint start no earlier than 2012-04-09 → start no earlier than 2013-04-09; resources none → WG |
| 4 | Attendance Secondary 2013 Guidance Notes Released | 2012-04-25 → 2013-04-25 (+365d) | 2012-04-25 → 2013-04-25 (+365d) |  | 180d → 266d |  | was named Attendance Secondary 2012 Guidance Notes Released; constraint start no earlier than 2012-04-25 → start no earlier than 2013-04-25; resources none → WG |
| 6 | **WED 2013 on DEWi** | 2012-04-16 → 2013-04-16 (+365d) | 2012-05-15 → 2013-05-15 (+365d) |  |  |  | was named WED 2012 on DEWi; resources none → M4/WG |
| 7 | WED 2013 DEWi development | 2012-04-16 → 2013-04-16 (+365d) | 2012-04-27 → 2013-04-29 (+367d) |  |  |  | was named WED 2012 DEWi development; constraint start no earlier than 2012-04-16 → start no earlier than 2013-04-16; resources none → M4/WG |
| 8 | WED 2013 DEWi UAT | 2012-04-30 → 2013-04-30 (+365d) | 2012-05-04 → 2013-05-06 (+367d) |  |  |  | was named WED 2012 DEWi UAT; resources none → M4/WG |
| 9 | WED 2013 DEWi rework | 2012-05-07 → 2013-05-07 (+365d) | 2012-05-09 → 2013-05-09 (+365d) |  |  |  | was named WED 2012 DEWi rework; constraint start no earlier than 2009-04-06 → start no earlier than 2013-05-07; resources none → M4/WG |
| 10 | WED 2013 Release to test DEWi site | 2012-05-10 → 2013-05-10 (+365d) | 2012-05-10 → 2013-05-10 (+365d) |  |  |  | was named WED 2012 Release to test DEWi site; resources none → M4/WG |
| 11 | WED 2013 DEWi UAT on test site | 2012-05-11 → 2013-05-13 (+367d) | 2012-05-14 → 2013-05-14 (+365d) |  |  |  | was named WED 2012 DEWi UAT on test site; resources none → M4/WG |
| 12 | WED 2013 Release to live DEWi site | 2012-05-15 → 2013-05-15 (+365d) | 2012-05-15 → 2013-05-15 (+365d) |  |  |  | was named WED 2012 Release to live DEWi site; resources none → M4/WG |
| 22 | **Spring SDF meetings** | 2012-02-16 → 2013-02-15 (+365d) | 2012-03-15 → 2013-03-15 (+365d) |  | 0d → -261d |  | resources none → Suppliers |
| 23 | Software Development Forum meeting | 2012-02-16 → 2013-02-15 (+365d) | 2012-02-16 → 2013-02-15 (+365d) |  | 0d → -261d |  | constraint start no earlier than 2012-02-16 → start no earlier than 2013-02-15; resources none → Suppliers/WG |
| 24 | Spec review period: PLASC, EOTAS & Attendance 2014 | 2012-02-17 → 2013-02-18 (+367d) | 2012-03-09 → 2013-03-11 (+367d) |  |  |  | was named Spec review period: PLASC, EOTAS & Attendance 2013; resources none → Suppliers |
| 25 | Software Development Forum meeting | 2012-03-15 → 2013-03-15 (+365d) | 2012-03-15 → 2013-03-15 (+365d) |  |  |  | constraint start no earlier than 2012-03-15 → start no earlier than 2013-03-15; resources none → Suppliers/WG |
| 28 | **CBDS (standard) change cycle** | 2012-04-02 → 2013-04-02 (+365d) | 2012-04-02 → 2013-04-02 (+365d) |  |  |  | resources none → WG |
| 29 | CBDS 1314 published - Pupil/School | 2012-04-02 → 2013-04-02 (+365d) | 2012-04-02 → 2013-04-02 (+365d) |  |  |  | was named CBDS 1213 published; constraint start no earlier than 2012-04-02 → start no earlier than 2013-04-02; resources none → WG |
| 31 | Publish 1314 Learning Activity codeset (look-up) | 2012-04-02 → 2013-04-02 (+365d) | 2012-04-02 → 2013-04-02 (+365d) |  |  |  | was named Publish 1213 Learning Activity codeset (look-up); constraint start no earlier than 2012-04-02 → start no earlier than 2013-04-02; resources none → WG |
| 32 | Publish 1314 Learning Activity Provider codeset (look-up) | 2012-04-02 → 2013-04-02 (+365d) | 2012-04-02 → 2013-04-02 (+365d) |  |  |  | was named Publish 1213 Learning Activity Provider codeset (look-up); constraint start no earlier than 2012-04-02 → start no earlier than 2013-04-02; resources none → WG |
| 34 | **Develop January PLASC and EOTAS 2014** | 2012-02-10 → 2013-02-08 (+364d) | 2012-07-02 → 2013-07-02 (+365d) | 102d → 103d |  |  | was named Develop January PLASC and EOTAS 2013; resources none → WG |
| 35 | **Specification** | 2012-02-10 → 2013-02-08 (+364d) | 2012-03-09 → 2013-03-08 (+364d) |  | 299d → 300d |  | resources none → WG |
| 36 | Draft specification release | 2012-02-10 → 2013-02-08 (+364d) | 2012-02-10 → 2013-02-08 (+364d) |  | 319d → 304d |  | constraint start no earlier than 2012-02-10 → start no earlier than 2013-02-08; resources none → WG |
| 37 | Supplier review period | 2012-02-13 → 2013-02-11 (+364d) | 2012-03-05 → 2013-03-04 (+364d) |  | 303d → 304d | none → 36 | constraint start no earlier than 2012-02-13 → none; resources none → Suppliers |
| 38 | Version 1 specification release | 2012-03-09 → 2013-03-08 (+364d) | 2012-03-09 → 2013-03-08 (+364d) |  | 299d → 300d |  | constraint start no earlier than 2012-03-09 → start no earlier than 2013-03-08; resources none → WG |
| 39 | **xslt development** | 2012-06-04 → 2013-06-04 (+365d) | 2012-06-27 → 2013-06-27 (+365d) |  |  |  | resources none → WG |
| 40 | Draft fileset release | 2012-06-04 → 2013-06-04 (+365d) | 2012-06-04 → 2013-06-04 (+365d) |  |  |  | constraint start no earlier than 2012-06-04 → start no earlier than 2013-06-04; resources none → WG |
| 41 | Supplier review period | 2012-06-05 → 2013-06-05 (+365d) | 2012-06-19 → 2013-06-19 (+365d) |  |  |  | resources none → Suppliers |
| 42 | Final fileset release | 2012-06-27 → 2013-06-27 (+365d) | 2012-06-27 → 2013-06-27 (+365d) |  |  |  | constraint start no earlier than 2012-06-27 → finish no earlier than 2013-06-27; resources none → WG |
| 43 | **DEWi developments** | 2012-07-02 → 2013-07-02 (+365d) | 2012-07-02 → 2013-07-02 (+365d) |  |  |  | resources none → M4/WG |
| 44 | Release to supplier test DEWi sites for PLASC & EOTAS 2014 | 2012-07-02 → 2013-07-02 (+365d) | 2012-07-02 → 2013-07-02 (+365d) |  |  |  | was named Release to supplier test DEWi sites for PLASC & EOTAS 2013; constraint start no earlier than 2012-07-02 → start no earlier than 2013-07-02; resources none → M4/WG |
| 45 | **January PLASC & EOTAS 2014 xslt and DEWi development** | 2012-04-16 → 2013-04-16 (+365d) | 2013-01-02 → 2014-01-02 (+365d) |  |  |  | was named January PLASC & EOTAS 2013 xslt and DEWi development; resources none → M4/WG |
| 46 | Jan & EOTAS 2014 xslt & DEWi development | 2012-04-16 → 2013-04-16 (+365d) | 2012-05-18 → 2013-05-20 (+367d) |  |  |  | was named Jan & EOTAS 2013 xslt & DEWi development; constraint start no earlier than 2012-04-16 → start no earlier than 2013-04-16; resources none → M4/WG |
| 47 | Jan & EOTAS 2014 xslt UAT | 2012-05-22 → 2013-05-21 (+364d) | 2012-06-01 → 2013-05-31 (+364d) |  | 228d → 229d |  | was named Jan & EOTAS 2013 xslt UAT; resources none → M4/WG |
| 48 | Jan & EOTAS 2014 xslt draft fileset release | 2012-06-04 → 2013-06-04 (+365d) | 2012-06-04 → 2013-06-04 (+365d) |  |  |  | was named Jan & EOTAS 2013 xslt draft fileset release; constraint start no earlier than 2012-06-04 → start no earlier than 2013-06-04; resources none → M4/WG |
| 49 | Jan & EOTAS 2014 DEWi UAT | 2012-06-04 → 2013-06-03 (+364d) | 2012-06-13 → 2013-06-12 (+364d) |  | 228d → 229d |  | was named Jan & EOTAS 2013 DEWi UAT; resources none → M4/WG |
| 50 | Jan & EOTAS 2014 xslt supplier review period | 2012-06-05 → 2013-06-05 (+365d) | 2012-06-19 → 2013-06-19 (+365d) |  |  |  | was named Jan & EOTAS 2013 xslt supplier review period; constraint start no earlier than 2012-06-05 → start no earlier than 2013-06-05; resources none → M4/WG |
| 51 | Jan & EOTAS 2014 xslt rework | 2012-06-20 → 2013-06-20 (+365d) | 2012-06-22 → 2013-06-24 (+367d) |  |  |  | was named Jan & EOTAS 2013 xslt rework; constraint start no earlier than 2012-06-20 → start no earlier than 2013-06-20; resources none → M4/WG |
| 52 | Jan & EOTAS 2014 xslt rework UAT | 2012-06-25 → 2013-06-25 (+365d) | 2012-06-26 → 2013-06-26 (+365d) |  |  |  | was named Jan & EOTAS 2013 xslt rework UAT; resources none → M4/WG |
| 53 | Jan & EOTAS 2014 DEWi rework | 2012-06-25 → 2013-06-25 (+365d) | 2012-06-27 → 2013-06-27 (+365d) |  |  |  | was named Jan & EOTAS 2013 DEWi rework; resources none → M4/WG |
| 54 | Jan & EOTAS 2014 xslt final fileset release | 2012-06-27 → 2013-06-27 (+365d) | 2012-06-27 → 2013-06-27 (+365d) |  |  |  | was named Jan & EOTAS 2013 xslt final fileset release; resources none → M4/WG |
| 55 | Jan & EOTAS 2014 Release to test DEWi site | 2012-06-27 → 2013-06-27 (+365d) | 2012-06-27 → 2013-06-27 (+365d) |  |  |  | was named Jan & EOTAS 2013 Release to test DEWi site; resources none → M4/WG |
| 56 | Jan & EOTAS 2014 DEWi UAT on test site | 2012-06-28 → 2013-06-28 (+365d) | 2012-07-02 → 2013-07-02 (+365d) |  |  |  | was named Jan & EOTAS 2013 DEWi UAT on test site; resources none → M4/WG |
| 57 | Jan & EOTAS 2014 Release to supplier test DEWi site | 2012-07-03 → 2013-07-03 (+365d) | 2012-07-03 → 2013-07-03 (+365d) |  |  |  | was named Jan & EOTAS 2013 Release to supplier test DEWi site; resources none → M4/WG |
| 58 | Jan & EOTAS 2014 Release to live DEWi site | 2013-01-02 → 2014-01-02 (+365d) | 2013-01-02 → 2014-01-02 (+365d) |  |  |  | was named Jan & EOTAS 2013 Release to live DEWi site; constraint start no earlier than 2013-01-02 → start no earlier than 2014-01-02; resources none → M4/WG |
| 61 | Post-16 PLASC 2013 Guidance Notes Released | 2012-08-24 → 2013-08-23 (+364d) | 2012-08-24 → 2013-08-23 (+364d) |  | 179d → 180d |  | was named Post-16 PLASC 2012 Guidance Notes Released; constraint start no earlier than 2012-08-24 → start no earlier than 2013-08-23; resources none → WG |
| 69 | **Develop Attendance 2014** | 2012-02-10 → 2013-02-08 (+364d) | 2012-10-01 → 2013-09-30 (+364d) |  | 153d → 154d |  | was named Develop Attendance 2013; resources none → WG |
| 70 | **Specification** | 2012-02-10 → 2013-02-08 (+364d) | 2012-03-09 → 2013-03-08 (+364d) |  | 299d → 300d |  | resources none → WG |
| 71 | Draft specification release | 2012-02-10 → 2013-02-08 (+364d) | 2012-02-10 → 2013-02-08 (+364d) |  | 319d → 320d |  | constraint start no earlier than 2012-02-10 → start no earlier than 2013-02-08; resources none → WG |
| 72 | Supplier review period | 2012-02-13 → 2013-02-13 (+366d) | 2012-03-05 → 2013-03-06 (+366d) |  | 303d → 302d |  | constraint start no earlier than 2012-02-13 → start no earlier than 2013-02-13; resources none → Suppliers |
| 73 | Version 1 specification release | 2012-03-09 → 2013-03-08 (+364d) | 2012-03-09 → 2013-03-08 (+364d) |  | 299d → 300d |  | constraint start no earlier than 2012-03-09 → start no earlier than 2013-03-08; resources none → WG |
| 74 | **xslt development** | 2012-09-03 → 2013-09-03 (+365d) | 2012-09-26 → 2013-09-26 (+365d) |  |  |  | resources none → WG |
| 75 | Draft fileset release | 2012-09-03 → 2013-09-03 (+365d) | 2012-09-03 → 2013-09-03 (+365d) |  |  |  | constraint start no earlier than 2012-09-03 → start no earlier than 2013-09-03; resources none → WG |
| 76 | Supplier review period | 2012-09-04 → 2013-09-04 (+365d) | 2012-09-18 → 2013-09-18 (+365d) |  |  |  | resources none → Suppliers |
| 77 | Final fileset release | 2012-09-26 → 2013-09-26 (+365d) | 2012-09-26 → 2013-09-26 (+365d) |  |  |  | constraint start no earlier than 2012-09-26 → start no earlier than 2013-09-26; resources none → WG |
| 78 | **DEWi developments** | 2012-10-01 → 2013-09-30 (+364d) | 2012-10-01 → 2013-09-30 (+364d) |  | 153d → 154d |  | resources none → M4/WG |
| 79 | Release to supplier test DEWi sites for Attendance & NDC 2014 | 2012-10-01 → 2013-09-30 (+364d) | 2012-10-01 → 2013-09-30 (+364d) |  | 153d → 154d |  | was named Release to supplier test DEWi sites for Attendance & NDC 2013; constraint start no earlier than 2012-10-01 → finish no earlier than 2013-09-30; resources none → M4/WG |
| 81 | Attendance Primary 2013 Guidance Notes Released | 2012-06-29 → 2013-06-28 (+364d) | 2012-06-29 → 2013-06-28 (+364d) |  | 219d → 220d |  | was named Attendance Primary 2012 Guidance Notes Released; constraint start no earlier than 2012-06-29 → start no earlier than 2013-06-28; resources none → WG |
| 83 | **Summer Attendance & NDC 2014 xslt and DEWi development** | 2012-07-30 → 2013-07-30 (+365d) | 2013-05-02 → 2014-05-02 (+365d) |  |  |  | was named Summer Attendance & NDC 2013 xslt and DEWi development; resources none → M4/WG |
| 84 | Summer 2014 xslt and DEWi development | 2012-07-30 → 2013-07-30 (+365d) | 2012-08-24 → 2013-08-26 (+367d) |  |  |  | was named Summer 2013 xslt and DEWi development; constraint start no earlier than 2012-07-30 → start no earlier than 2013-07-30; resources none → M4/WG |
| 85 | Summer 2014 xslt UAT | 2012-08-27 → 2013-08-27 (+365d) | 2012-08-31 → 2013-09-02 (+367d) |  |  |  | was named Summer 2013 xslt UAT; resources none → M4/WG |
| 86 | Summer 2014 xslt draft fileset release | 2012-09-03 → 2013-09-03 (+365d) | 2012-09-03 → 2013-09-03 (+365d) |  |  |  | was named Summer 2013 xslt draft fileset release; resources none → M4/WG |
| 87 | Summer 2014 xslt supplier review period | 2012-09-04 → 2013-09-04 (+365d) | 2012-09-18 → 2013-09-18 (+365d) |  |  |  | was named Summer 2013 xslt supplier review period; resources none → M4/WG |
| 88 | Summer 2014 DEWi UAT | 2012-09-03 → 2013-09-03 (+365d) | 2012-09-07 → 2013-09-09 (+367d) |  |  |  | was named Summer 2013 DEWi UAT; resources none → M4/WG |
| 89 | Summer 2014 xslt rework | 2012-09-19 → 2013-09-19 (+365d) | 2012-09-24 → 2013-09-24 (+365d) |  |  |  | was named Summer 2013 xslt rework; resources none → M4/WG |
| 90 | Summer 2014 xslt rework UAT | 2012-09-25 → 2013-09-25 (+365d) | 2012-09-26 → 2013-09-26 (+365d) |  |  |  | was named Summer 2013 xslt rework UAT; resources none → M4/WG |
| 91 | Summer 2014 DEWi rework | 2012-09-19 → 2013-09-19 (+365d) | 2012-09-25 → 2013-09-25 (+365d) |  |  |  | was named Summer 2013 DEWi rework; resources none → M4/WG |
| 92 | Summer 2014 Release to test DEWi site for NDC & Attendance collections 2013 | 2012-09-26 → 2013-09-26 (+365d) | 2012-09-26 → 2013-09-26 (+365d) |  |  |  | was named Summer 2013 Release to test DEWi site for NDC & Attendance collections 2013; resources none → M4/WG |
| 93 | Summer 2014 xslt final fileset release | 2012-09-27 → 2013-09-27 (+365d) | 2012-09-27 → 2013-09-27 (+365d) |  |  |  | was named Summer 2013 xslt final fileset release; resources none → M4/WG |
| 94 | Summer 2014 DEWi UAT on test site | 2012-09-28 → 2013-09-30 (+367d) | 2012-10-02 → 2013-10-02 (+365d) |  |  |  | was named Summer 2013 DEWi UAT on test site; resources none → M4/WG |
| 95 | Summer 2014 Release to supplier test DEWi site for NDC & Attendance collections 2013 | 2012-10-03 → 2013-10-03 (+365d) | 2012-10-03 → 2013-10-03 (+365d) |  |  |  | was named Summer 2013 Release to supplier test DEWi site for NDC & Attendance collections 2013; resources none → M4/WG |
| 96 | Summer 2014 Release to live DEWi site for NDC & Attendance collections 2013 | 2013-05-02 → 2014-05-02 (+365d) | 2013-05-02 → 2014-05-02 (+365d) |  |  |  | was named Summer 2013 Release to live DEWi site for NDC & Attendance collections 2013; constraint start no earlier than 2013-05-02 → start no earlier than 2014-05-02; resources none → M4/WG |
| 98 | **Summer SDF meeting** | 2012-06-07 → 2013-06-07 (+365d) | 2012-06-29 → 2013-07-01 (+367d) |  |  |  | resources none → Suppliers |

| ID | Task | Start | Finish | Duration | Total float | Other |
| --- | --- | --- | --- | --- | --- | --- |
| 99 | Software Development Forum meeting | 2012-06-07 → 2013-06-07 (+365d) | 2012-06-07 → 2013-06-07 (+365d) |  |  | constraint start no earlier than 2012-06-07 → start no earlier than 2013-06-07; resources none → Suppliers/WG |
| 100 | Spec review period | 2012-06-08 → 2013-06-10 (+367d) | 2012-06-29 → 2013-07-01 (+367d) |  |  | resources none → Suppliers |
| 101 | **Develop NDC 2014** | 2012-06-01 → 2013-05-31 (+364d) | 2012-10-01 → 2013-10-01 (+365d) | 87d → 88d |  | was named Develop NDC 2013; resources none → WG |
| 102 | **Specification** | 2012-06-01 → 2013-05-31 (+364d) | 2012-06-27 → 2013-06-25 (+363d) | 19d → 18d | 221d → 223d | resources none → WG |
| 103 | Draft specification release | 2012-06-01 → 2013-05-31 (+364d) | 2012-06-01 → 2013-05-31 (+364d) |  | 222d → 223d | constraint start no earlier than 2012-06-01 → start no earlier than 2013-05-31; resources none → WG |
| 104 | Supplier review period | 2012-06-04 → 2013-06-03 (+364d) | 2012-06-25 → 2013-06-24 (+364d) |  | 222d → 223d | resources none → Suppliers |
| 105 | Version 1 specification release | 2012-06-27 → 2013-06-25 (+363d) | 2012-06-27 → 2013-06-25 (+363d) |  | 221d → 223d | resources none → WG |
| 106 | **xslt development** | 2012-09-03 → 2013-09-03 (+365d) | 2012-09-27 → 2013-09-27 (+365d) |  |  | resources none → WG |
| 107 | Draft fileset release | 2012-09-03 → 2013-09-03 (+365d) | 2012-09-03 → 2013-09-03 (+365d) |  | 161d → 155d | constraint start no earlier than 2012-09-03 → start no earlier than 2013-09-03; resources none → WG |
| 108 | Supplier review period | 2012-09-04 → 2013-09-04 (+365d) | 2012-09-18 → 2013-09-18 (+365d) |  |  | resources none → Suppliers |
| 109 | Final fileset release | 2012-09-27 → 2013-09-19 (+357d) | 2012-09-27 → 2013-09-27 (+365d) | 1d → 7d |  | constraint start no earlier than 2012-09-27 → finish no earlier than 2013-09-27; resources none → WG |
| 110 | **DEWi developments** | 2012-10-01 → 2013-10-01 (+365d) | 2012-10-01 → 2013-10-01 (+365d) |  |  | resources none → M4/WG |
| 111 | Release to supplier test DEWi sites for Attendance & NDC 2014 | 2012-10-01 → 2013-10-01 (+365d) | 2012-10-01 → 2013-10-01 (+365d) |  |  | was named Release to supplier test DEWi sites for Attendance & NDC 2013; constraint start no earlier than 2012-10-01 → start no earlier than 2013-10-01; resources none → M4/WG |
| 118 | **Autumn SDF meetings** | 2012-10-09 → 2013-10-09 (+365d) | 2012-11-06 → 2013-11-06 (+365d) |  |  | resources none → Suppliers |
| 119 | Software Development Forum meeting | 2012-10-09 → 2013-10-09 (+365d) | 2012-10-09 → 2013-10-09 (+365d) |  |  | constraint start no earlier than 2012-10-09 → start no earlier than 2013-10-09; resources none → Suppliers/WG |
| 120 | Spec review period | 2012-10-10 → 2013-10-10 (+365d) | 2012-10-31 → 2013-10-31 (+365d) |  |  | resources none → Suppliers |
| 121 | Software Development Forum meeting | 2012-11-06 → 2013-11-06 (+365d) | 2012-11-06 → 2013-11-06 (+365d) |  |  | constraint start no earlier than 2012-11-06 → start no earlier than 2013-11-06; resources none → Suppliers/WG |
| 124 | **Develop Post-16 September PLASC 2014** | 2012-10-04 → 2013-10-04 (+365d) | 2013-04-11 → 2014-04-11 (+365d) |  |  | was named Develop Post-16 September PLASC 2013; resources none → WG |
| 125 | **Specification** | 2012-10-04 → 2013-10-04 (+365d) | 2012-11-01 → 2013-11-01 (+365d) |  |  | resources none → WG |
| 126 | Draft specification release | 2012-10-04 → 2013-10-04 (+365d) | 2012-10-04 → 2013-10-04 (+365d) |  |  | constraint start no earlier than 2012-10-04 → start no earlier than 2013-10-04; resources none → WG |
| 127 | Supplier review period | 2012-10-05 → 2013-10-07 (+367d) | 2012-10-26 → 2013-10-28 (+367d) |  |  | resources none → Suppliers |
| 128 | Version 1 specification release | 2012-11-01 → 2013-11-01 (+365d) | 2012-11-01 → 2013-11-01 (+365d) |  |  | constraint start no earlier than 2012-11-01 → start no earlier than 2013-11-01; resources none → WG |
| 129 | **xslt development** | 2012-11-20 → 2013-11-20 (+365d) | 2013-04-11 → 2014-04-11 (+365d) |  |  | resources none → WG |
| 130 | Draft fileset release | 2012-11-20 → 2013-11-20 (+365d) | 2012-11-20 → 2013-11-20 (+365d) |  |  | constraint start no earlier than 2012-11-20 → start no earlier than 2013-11-20; resources none → WG |
| 131 | Supplier review period | 2012-11-21 → 2013-11-21 (+365d) | 2012-12-05 → 2013-12-05 (+365d) |  |  | resources none → Suppliers |
| 132 | Final fileset release | 2012-12-13 → 2013-12-13 (+365d) | 2012-12-13 → 2013-12-13 (+365d) |  |  | constraint start no earlier than 2012-12-13 → start no earlier than 2013-12-13; resources none → WG |
| 133 | Update of fileset release with 14/15 look-ups | 2013-04-11 → 2014-04-11 (+365d) | 2013-04-11 → 2014-04-11 (+365d) |  |  | was named Update of fileset release with 13/14 look-ups; constraint start no earlier than 2013-04-11 → start no earlier than 2014-04-11; resources none → WG |
| 134 | **DEWi developments** | 2012-12-13 → 2013-12-13 (+365d) | 2013-04-05 → 2014-04-04 (+364d) | 82d → 81d | 19d → 20d | resources none → M4/WG |
| 135 | Release to supplier test DEWi sites for Post-16 September PLASC 2014 | 2012-12-13 → 2013-12-13 (+365d) | 2012-12-13 → 2013-12-13 (+365d) |  |  | was named Release to supplier test DEWi sites for Post-16 September PLASC 2013; constraint start no earlier than 2012-12-13 → start no earlier than 2013-12-13; resources none → M4/WG |
| 136 | Release update with look-ups to supplier test DEWi site Post-16 September PLASC 2014 | 2013-04-05 → 2014-04-04 (+364d) | 2013-04-05 → 2014-04-04 (+364d) |  | 19d → 20d | was named Release update with look-ups to supplier test DEWi site Post-16 September PLASC 2013; constraint start no earlier than 2013-04-05 → start no earlier than 2014-04-04; resources none → M4/WG |
| 138 | **Post-16 Sept 2014 xslt and DEWi development** | 2012-11-01 → 2013-11-01 (+365d) | 2013-04-10 → 2014-04-10 (+365d) |  |  | was named Post-16 Sept 2013 xslt and DEWi development; resources none → M4/WG |
| 139 | Sept 2014 xslt and DEWi development | 2012-11-01 → 2013-11-01 (+365d) | 2012-11-14 → 2013-11-14 (+365d) |  |  | was named Sept 2013 xslt and DEWi development; constraint start no earlier than 2012-11-01 → start no earlier than 2013-11-01; resources none → M4/WG |
| 140 | Sept 2014 xslt UAT | 2012-11-15 → 2013-11-15 (+365d) | 2012-11-19 → 2013-11-19 (+365d) |  |  | was named Sept 2013 xslt UAT; resources none → M4/WG |
| 141 | Sept 2014 xslt draft fileset release | 2012-11-20 → 2013-11-20 (+365d) | 2012-11-20 → 2013-11-20 (+365d) |  |  | was named Sept 2013 xslt draft fileset release; resources none → M4/WG |
| 142 | Sept 2014 xslt supplier review period | 2012-11-21 → 2013-11-21 (+365d) | 2012-12-05 → 2013-12-05 (+365d) |  |  | was named Sept 2013 xslt supplier review period; resources none → M4/WG |
| 143 | September 2014 DEWi UAT | 2012-11-20 → 2013-11-20 (+365d) | 2012-11-22 → 2013-11-22 (+365d) |  |  | was named September 2013 DEWi UAT; resources none → M4/WG |
| 144 | Sept 2014 xslt rework | 2012-12-06 → 2013-12-06 (+365d) | 2012-12-10 → 2013-12-10 (+365d) |  |  | was named Sept 2013 xslt rework; resources none → M4/WG |
| 145 | Sept 2014 xslt rework UAT | 2012-12-11 → 2013-12-11 (+365d) | 2012-12-12 → 2013-12-12 (+365d) |  |  | was named Sept 2013 xslt rework UAT; resources none → M4/WG |
| 146 | September 2014 DEWi rework | 2012-12-06 → 2013-12-06 (+365d) | 2012-12-12 → 2013-12-12 (+365d) |  |  | was named September 2013 DEWi rework; resources none → M4/WG |
| 147 | September 2014 Release to test DEWi site | 2012-12-13 → 2013-12-13 (+365d) | 2012-12-13 → 2013-12-13 (+365d) |  |  | was named September 2013 Release to test DEWi site; resources none → M4/WG |
| 148 | Sept 2014 xslt final fileset release | 2012-12-13 → 2013-12-13 (+365d) | 2012-12-13 → 2013-12-13 (+365d) |  |  | was named Sept 2013 xslt final fileset release; resources none → M4/WG |
| 149 | September 2014 DEWi UAT on test site | 2012-12-14 → 2013-12-16 (+367d) | 2012-12-18 → 2013-12-18 (+365d) |  |  | was named September 2013 DEWi UAT on test site; resources none → M4/WG |
| 150 | September 2014 Release to supplier test DEWi site | 2012-12-19 → 2013-12-19 (+365d) | 2012-12-19 → 2013-12-19 (+365d) |  |  | was named September 2013 Release to supplier test DEWi site; constraint start no earlier than 2009-12-21 → start no earlier than 2013-12-19; resources none → M4/WG |
| 151 | Sept 2014 xslt and DEWi inclusion of 14/15 look-ups | 2013-04-01 → 2014-04-01 (+365d) | 2013-04-04 → 2014-04-04 (+365d) |  |  | was named Sept 2013 xslt and DEWi inclusion of 13/14 look-ups; constraint start no earlier than 2013-04-01 → start no earlier than 2014-04-01; resources none → M4/WG |
| 152 | Sept 2014 xslt and DEWi UAT on 14/15 look-ups update | 2013-04-05 → 2014-04-07 (+367d) | 2013-04-09 → 2014-04-09 (+365d) |  |  | was named Sept 2013 xslt and DEWi UAT on 13/14 look-ups update; resources none → M4/WG |
| 153 | Sept 2014 xslt update release | 2013-04-10 → 2014-04-10 (+365d) | 2013-04-10 → 2014-04-10 (+365d) |  |  | was named Sept 2013 xslt update release; resources none → M4/WG |
| 154 | September 2014 Release to live DEWi site | 2013-04-10 → 2014-04-10 (+365d) | 2013-04-10 → 2014-04-10 (+365d) |  |  | was named September 2013 Release to live DEWi site; resources none → M4/WG |
| 158 | Jan PLASC & EOTAS 2014 Guidance Notes Released | 2012-12-10 → 2013-12-10 (+365d) | 2012-12-10 → 2013-12-10 (+365d) |  |  | was named Jan PLASC & EOTAS 2013 Guidance Notes Released; constraint start no earlier than 2012-12-10 → start no earlier than 2013-12-10; resources none → WG |

## Version 3 (saved 2014-02-10)

Last finish 2014-05-02 → 2015-05-01 (+364d).

Added:

| ID | Task | Duration | Start | Finish | Constraint | Resources |
| --- | --- | --- | --- | --- | --- | --- |
| 81 | Post-16 2014 Guidance Notes Released | 1d | 2014-07-03 | 2014-07-03 | start no earlier than 2014-07-03 | WG |

Removed: 61 Post-16 PLASC 2013 Guidance Notes Released; 115 s2s user audit; 120 Spec review period; 160 Data Demons Released

Changed:

| ID | Task | Start | Finish | Duration | Total float | Predecessors | Other |
| --- | --- | --- | --- | --- | --- | --- | --- |
| 2 | NDC 2014 Reporting Arrangements Released | 2013-04-09 → 2014-04-08 (+364d) | 2013-04-09 → 2014-04-08 (+364d) |  |  |  | was named NDC 2013 Reporting Arrangements Released; constraint start no earlier than 2013-04-09 → start no earlier than 2014-04-08 |
| 4 | Attendance Secondary 2014 Guidance Notes Released | 2013-04-25 → 2014-04-24 (+364d) | 2013-04-25 → 2014-04-24 (+364d) |  |  |  | was named Attendance Secondary 2013 Guidance Notes Released; constraint start no earlier than 2013-04-25 → start no earlier than 2014-04-24 |
| 7 | **WED 2014 on DEWi** | 2013-04-16 → 2014-04-15 (+364d) | 2013-05-15 → 2014-05-16 (+366d) | 22d → 24d | 252d → 250d |  | was named WED 2013 on DEWi |
| 8 | WED 2014 DEWi development | 2013-04-16 → 2014-04-15 (+364d) | 2013-04-29 → 2014-04-28 (+364d) |  |  |  | was named WED 2013 DEWi development; constraint start no earlier than 2013-04-16 → start no earlier than 2014-04-15 |
| 9 | WED 2014 DEWi UAT | 2013-04-30 → 2014-04-29 (+364d) | 2013-05-06 → 2014-05-05 (+364d) |  |  |  | was named WED 2013 DEWi UAT; constraint start no earlier than 2009-03-30 → start no earlier than 2014-04-29 |
| 10 | WED 2014 DEWi rework | 2013-05-07 → 2014-05-07 (+365d) | 2013-05-09 → 2014-05-09 (+365d) |  | 252d → 251d |  | was named WED 2013 DEWi rework; constraint start no earlier than 2013-05-07 → start no earlier than 2014-05-07 |
| 11 | WED 2014 Release to test DEWi site | 2013-05-10 → 2014-05-12 (+367d) | 2013-05-10 → 2014-05-12 (+367d) |  | 252d → 251d |  | was named WED 2013 Release to test DEWi site; constraint none → start no earlier than 2014-05-12 |
| 12 | WED 2014 DEWi UAT on test site | 2013-05-13 → 2014-05-14 (+366d) | 2013-05-14 → 2014-05-15 (+366d) |  | 252d → 250d |  | was named WED 2013 DEWi UAT on test site; constraint none → start no earlier than 2014-05-14 |
| 13 | WED 2014 Release to live DEWi site | 2013-05-15 → 2014-05-16 (+366d) | 2013-05-15 → 2014-05-16 (+366d) |  | 252d → 250d |  | was named WED 2013 Release to live DEWi site; constraint start no earlier than 2009-08-03 → start no earlier than 2014-05-16 |
| 15 | Review and update the ULN collection, also taking account of CTF changes | 2013-04-16 → 2014-04-15 (+364d) | 2013-04-16 → 2014-04-15 (+364d) |  |  |  | constraint start no earlier than 2013-04-16 → start no earlier than 2014-04-15 |
| 18 | CTF14 draft release to suppliers | 2013-02-01 → 2014-02-03 (+367d) | 2013-02-01 → 2014-02-03 (+367d) |  | 325d → 324d |  | was named CTF13 draft release to suppliers; constraint start no earlier than 2013-02-01 → start no earlier than 2014-02-03 |
| 20 | A_COMP 2014 Review | 2013-02-01 → 2014-02-03 (+367d) | 2013-04-02 → 2014-04-03 (+366d) | 43d → 44d | 283d → 281d |  | was named A_COMP 2013 Review; constraint start no earlier than 2013-02-01 → finish no earlier than 2014-04-03 |
| 21 | CTF14 final release to suppliers | 2013-03-01 → 2014-03-03 (+367d) | 2013-03-01 → 2014-03-03 (+367d) |  | 305d → 304d |  | was named CTF13 final release to suppliers; constraint start no earlier than 2013-03-01 → start no earlier than 2014-03-03 |
| 23 | **Spring SDF meetings** | 2013-02-15 → 2014-02-11 (+361d) | 2013-03-15 → 2014-03-18 (+368d) | 21d → 26d | -261d → -518d |  |  |
| 24 | Software Development Forum meeting | 2013-02-15 → 2014-02-11 (+361d) | 2013-02-15 → 2014-02-11 (+361d) |  | -261d → -518d |  | constraint start no earlier than 2013-02-15 → start no earlier than 2014-02-11 |
| 25 | Spec review period: PLASC, EOTAS & Attendance 2015 | 2013-02-18 → 2014-02-13 (+360d) | 2013-03-11 → 2014-03-06 (+360d) |  | 298d → 300d |  | was named Spec review period: PLASC, EOTAS & Attendance 2014; constraint finish no earlier than 2011-03-02 → start no earlier than 2014-02-13 |
| 26 | Software Development Forum meeting | 2013-03-15 → 2014-03-18 (+368d) | 2013-03-15 → 2014-03-18 (+368d) |  | 295d → 293d |  | constraint start no earlier than 2013-03-15 → start no earlier than 2014-03-18 |
| 29 | **CBDS (standard) change cycle** | 2013-04-02 → 2014-04-02 (+365d) | 2013-04-02 → 2014-04-02 (+365d) |  | 283d → 282d |  |  |
| 30 | CBDS 1415 published - Pupil/School | 2013-04-02 → 2014-04-02 (+365d) | 2013-04-02 → 2014-04-02 (+365d) |  | 283d → 282d |  | was named CBDS 1314 published - Pupil/School; constraint start no earlier than 2013-04-02 → start no earlier than 2014-04-02 |
| 31 | A_COMP published | 2013-04-02 → 2014-04-02 (+365d) | 2013-04-02 → 2014-04-02 (+365d) |  | 283d → 282d |  | constraint start no earlier than 2013-04-02 → start no earlier than 2014-04-02 |
| 32 | Publish 1415 Learning Activity codeset (look-up) | 2013-04-02 → 2014-04-02 (+365d) | 2013-04-02 → 2014-04-02 (+365d) |  | 283d → 282d |  | was named Publish 1314 Learning Activity codeset (look-up); constraint start no earlier than 2013-04-02 → start no earlier than 2014-04-02 |
| 33 | Publish 1415 Learning Activity Provider codeset (look-up) | 2013-04-02 → 2014-04-02 (+365d) | 2013-04-02 → 2014-04-02 (+365d) |  | 283d → 282d |  | was named Publish 1314 Learning Activity Provider codeset (look-up); constraint start no earlier than 2013-04-02 → start no earlier than 2014-04-02 |
| 35 | **Develop January PLASC and EOTAS 2015** | 2013-02-08 → 2014-02-11 (+368d) | 2013-07-02 → 2014-07-03 (+366d) |  | 218d → 216d |  | was named Develop January PLASC and EOTAS 2014 |
| 36 | **Specification** | 2013-02-08 → 2014-02-11 (+368d) | 2013-03-08 → 2014-03-07 (+364d) | 21d → 19d |  |  |  |
| 37 | Draft specification release | 2013-02-08 → 2014-02-11 (+368d) | 2013-02-08 → 2014-02-11 (+368d) |  | 304d → 302d |  | constraint start no earlier than 2013-02-08 → start no earlier than 2014-02-11 |
| 38 | Supplier review period | 2013-02-11 → 2014-02-12 (+366d) | 2013-03-04 → 2014-03-05 (+366d) |  | 304d → 302d |  | constraint none → start no earlier than 2014-02-11 |
| 39 | Version 1 specification release | 2013-03-08 → 2014-03-07 (+364d) | 2013-03-08 → 2014-03-07 (+364d) |  |  |  | constraint start no earlier than 2013-03-08 → start no earlier than 2014-03-07 |
| 40 | **xslt development** | 2013-06-04 → 2014-06-02 (+363d) | 2013-06-27 → 2014-06-26 (+364d) | 18d → 19d |  |  |  |
| 41 | Draft fileset release | 2013-06-04 → 2014-06-02 (+363d) | 2013-06-04 → 2014-06-02 (+363d) |  | 226d → 227d |  | constraint start no earlier than 2013-06-04 → start no earlier than 2014-06-02 |
| 42 | Supplier review period | 2013-06-05 → 2014-06-03 (+363d) | 2013-06-19 → 2014-06-17 (+363d) |  | 226d → 227d |  | constraint none → start no earlier than 2014-06-02 |
| 43 | Final fileset release | 2013-06-27 → 2014-06-26 (+364d) | 2013-06-27 → 2014-06-26 (+364d) |  |  |  | constraint finish no earlier than 2013-06-27 → start no earlier than 2014-06-26 |
| 44 | **DEWi developments** | 2013-07-02 → 2014-07-03 (+366d) | 2013-07-02 → 2014-07-03 (+366d) |  | 218d → 216d |  |  |
| 45 | Release to supplier test DEWi sites for PLASC & EOTAS 2015 | 2013-07-02 → 2014-07-03 (+366d) | 2013-07-02 → 2014-07-03 (+366d) |  | 218d → 216d |  | was named Release to supplier test DEWi sites for PLASC & EOTAS 2014; constraint start no earlier than 2013-07-02 → finish no earlier than 2014-07-03 |
| 46 | **January PLASC & EOTAS 2015 xslt and DEWi development** | 2013-04-16 → 2014-04-15 (+364d) | 2014-01-02 → 2015-01-02 (+365d) | 188d → 189d | 86d → 85d |  | was named January PLASC & EOTAS 2014 xslt and DEWi development |
| 47 | Jan & EOTAS 2015 xslt & DEWi development | 2013-04-16 → 2014-04-15 (+364d) | 2013-05-20 → 2014-05-19 (+364d) |  |  |  | was named Jan & EOTAS 2014 xslt & DEWi development; constraint start no earlier than 2013-04-16 → start no earlier than 2014-04-15 |
| 48 | Jan & EOTAS 2015 xslt UAT | 2013-05-21 → 2014-05-20 (+364d) | 2013-05-31 → 2014-05-30 (+364d) |  |  |  | was named Jan & EOTAS 2014 xslt UAT; constraint start no earlier than 2012-05-22 → start no earlier than 2014-05-20 |
| 49 | Jan & EOTAS 2015 xslt draft fileset release | 2013-06-04 → 2014-06-05 (+366d) | 2013-06-04 → 2014-06-05 (+366d) |  | 238d → 236d |  | was named Jan & EOTAS 2014 xslt draft fileset release; constraint start no earlier than 2013-06-04 → start no earlier than 2014-06-05 |
| 50 | Jan & EOTAS 2015 DEWi UAT | 2013-06-03 → 2014-06-03 (+365d) | 2013-06-12 → 2014-06-12 (+365d) |  | 229d → 228d |  | was named Jan & EOTAS 2014 DEWi UAT; constraint start no earlier than 2012-06-04 → start no earlier than 2014-06-03 |
| 51 | Jan & EOTAS 2015 xslt supplier review period | 2013-06-05 → 2014-06-06 (+366d) | 2013-06-19 → 2014-06-20 (+366d) |  | 227d → 225d |  | was named Jan & EOTAS 2014 xslt supplier review period; constraint start no earlier than 2013-06-05 → start no earlier than 2014-06-06 |
| 52 | Jan & EOTAS 2015 xslt rework | 2013-06-20 → 2014-06-23 (+368d) | 2013-06-24 → 2014-06-25 (+366d) |  | 217d → 215d |  | was named Jan & EOTAS 2014 xslt rework; constraint start no earlier than 2013-06-20 → start no earlier than 2014-06-23 |
| 53 | Jan & EOTAS 2015 xslt rework UAT | 2013-06-25 → 2014-06-26 (+366d) | 2013-06-26 → 2014-06-27 (+366d) |  | 217d → 215d |  | was named Jan & EOTAS 2014 xslt rework UAT; constraint start no earlier than 2008-12-11 → start no earlier than 2014-06-26 |
| 54 | Jan & EOTAS 2015 DEWi rework | 2013-06-25 → 2014-06-26 (+366d) | 2013-06-27 → 2014-06-30 (+368d) |  | 221d → 219d |  | was named Jan & EOTAS 2014 DEWi rework; constraint start no earlier than 2012-06-14 → start no earlier than 2014-06-26 |
| 55 | Jan & EOTAS 2015 xslt final fileset release | 2013-06-27 → 2014-06-30 (+368d) | 2013-06-27 → 2014-06-30 (+368d) |  | 221d → 219d |  | was named Jan & EOTAS 2014 xslt final fileset release; constraint start no earlier than 2012-06-27 → start no earlier than 2014-06-30 |
| 56 | Jan & EOTAS 2015 Release to test DEWi site | 2013-06-27 → 2014-06-30 (+368d) | 2013-06-27 → 2014-06-30 (+368d) |  | 217d → 215d |  | was named Jan & EOTAS 2014 Release to test DEWi site; constraint start no earlier than 2012-06-27 → start no earlier than 2014-06-30 |
| 57 | Jan & EOTAS 2015 DEWi UAT on test site | 2013-06-28 → 2014-07-01 (+368d) | 2013-07-02 → 2014-07-03 (+366d) |  | 217d → 215d |  | was named Jan & EOTAS 2014 DEWi UAT on test site; constraint start no earlier than 2009-07-08 → start no earlier than 2014-07-01 |
| 58 | Jan & EOTAS 2015 Release to supplier test DEWi site | 2013-07-03 → 2014-07-04 (+366d) | 2013-07-03 → 2014-07-04 (+366d) |  | 217d → 215d |  | was named Jan & EOTAS 2014 Release to supplier test DEWi site; constraint start no earlier than 2009-07-14 → start no earlier than 2014-07-04 |
| 59 | Jan & EOTAS 2015 Release to live DEWi site | 2014-01-02 → 2015-01-02 (+365d) | 2014-01-02 → 2015-01-02 (+365d) |  | 86d → 85d |  | was named Jan & EOTAS 2014 Release to live DEWi site; constraint start no earlier than 2014-01-02 → start no earlier than 2015-01-02 |
| 61 | Data removal - PLASC 2014 data | 2013-08-23 → 2014-08-22 (+364d) | 2013-08-23 → 2014-08-22 (+364d) |  |  |  | was named Data removal - PLASC 2013 data; constraint start no earlier than 2013-08-23 → start no earlier than 2014-08-22 |
| 63 | Fixed reports for NDC 2014 | 2013-08-27 → 2014-09-23 (+392d) | 2013-09-24 → 2014-10-21 (+392d) |  | 157d → 137d |  | was named Fixed reports for NDC 2013; constraint start no earlier than 2013-08-27 → start no earlier than 2014-09-23 |
| 64 | Data removal - NDC 2014 data | 2013-09-25 → 2014-10-22 (+392d) | 2013-09-25 → 2014-10-22 (+392d) |  | 157d → 137d |  | was named Data removal - NDC 2013 data; constraint start no earlier than 2009-09-30 → start no earlier than 2014-09-24 |
| 65 | Data removal - Attendance 2014 | 2013-10-25 → 2014-10-21 (+361d) | 2013-10-25 → 2014-10-21 (+361d) |  | 135d → 138d |  | was named Data removal - Attendance 2013; constraint start no earlier than 2013-10-25 → start no earlier than 2014-10-21 |
| 67 | **Develop Attendance 2014** | 2013-02-08 → 2014-02-11 (+368d) | 2013-09-30 → 2014-09-30 (+365d) | 167d → 166d | 154d → 153d |  |  |
| 68 | **Specification** | 2013-02-08 → 2014-02-11 (+368d) | 2013-03-08 → 2014-03-11 (+368d) |  | 300d → 298d |  |  |
| 69 | Draft specification release | 2013-02-08 → 2014-02-11 (+368d) | 2013-02-08 → 2014-02-11 (+368d) |  | 320d → 303d |  | constraint start no earlier than 2013-02-08 → start no earlier than 2014-02-11 |
| 70 | Supplier review period | 2013-02-13 → 2014-02-12 (+364d) | 2013-03-06 → 2014-03-04 (+363d) | 16d → 15d | 302d → 303d | none → 69 | constraint start no earlier than 2013-02-13 → none |
| 71 | Version 1 specification release | 2013-03-08 → 2014-03-11 (+368d) | 2013-03-08 → 2014-03-11 (+368d) |  | 300d → 298d |  | constraint start no earlier than 2013-03-08 → start no earlier than 2014-03-11 |
| 72 | **xslt development** | 2013-09-03 → 2014-09-10 (+372d) | 2013-09-26 → 2014-09-26 (+365d) | 18d → 13d | 156d → 155d |  |  |
| 73 | Draft fileset release | 2013-09-03 → 2014-09-10 (+372d) | 2013-09-03 → 2014-09-10 (+372d) |  | 161d → 155d |  | constraint start no earlier than 2013-09-03 → start no earlier than 2014-09-10 |
| 74 | Supplier review period | 2013-09-04 → 2014-09-11 (+372d) | 2013-09-18 → 2014-09-25 (+372d) |  | 161d → 155d |  | constraint start no earlier than 2010-09-07 → start no earlier than 2014-09-11 |
| 75 | Final fileset release | 2013-09-26 → 2014-09-26 (+365d) | 2013-09-26 → 2014-09-26 (+365d) |  | 156d → 155d |  | constraint start no earlier than 2013-09-26 → start no earlier than 2014-09-01 |
| 76 | **DEWi developments** | 2013-09-30 → 2014-09-30 (+365d) | 2013-09-30 → 2014-09-30 (+365d) |  | 154d → 153d |  |  |
| 77 | Release to supplier test DEWi sites for Attendance & NDC 2015 | 2013-09-30 → 2014-09-30 (+365d) | 2013-09-30 → 2014-09-30 (+365d) |  | 154d → 153d |  | was named Release to supplier test DEWi sites for Attendance & NDC 2014; constraint finish no earlier than 2013-09-30 → start no earlier than 2014-09-30 |
| 79 | Attendance Primary 2014 Guidance Notes Released | 2013-06-28 → 2014-06-27 (+364d) | 2013-06-28 → 2014-06-27 (+364d) |  |  |  | was named Attendance Primary 2013 Guidance Notes Released; constraint start no earlier than 2013-06-28 → start no earlier than 2014-06-27 |
| 83 | **Summer Attendance & NDC 2015 xslt and DEWi development** | 2013-07-30 → 2014-07-29 (+364d) | 2014-05-02 → 2015-05-01 (+364d) |  |  |  | was named Summer Attendance & NDC 2014 xslt and DEWi development |
| 84 | Summer 2015 xslt and DEWi development | 2013-07-30 → 2014-07-29 (+364d) | 2013-08-26 → 2014-08-25 (+364d) |  |  |  | was named Summer 2014 xslt and DEWi development; constraint start no earlier than 2013-07-30 → start no earlier than 2014-07-29 |
| 85 | Summer 2015 xslt UAT | 2013-08-27 → 2014-08-26 (+364d) | 2013-09-02 → 2014-09-01 (+364d) |  |  |  | was named Summer 2014 xslt UAT; constraint start no earlier than 2009-05-25 → start no earlier than 2014-08-26 |
| 86 | Summer 2015 xslt draft fileset release | 2013-09-03 → 2014-09-02 (+364d) | 2013-09-03 → 2014-09-02 (+364d) |  |  |  | was named Summer 2014 xslt draft fileset release; constraint start no earlier than 2010-09-06 → start no earlier than 2014-09-02 |
| 87 | Summer 2015 xslt supplier review period | 2013-09-04 → 2014-09-03 (+364d) | 2013-09-18 → 2014-09-17 (+364d) |  |  |  | was named Summer 2014 xslt supplier review period; constraint none → start no earlier than 2014-09-03 |
| 88 | Summer 2015 DEWi UAT | 2013-09-03 → 2014-09-02 (+364d) | 2013-09-09 → 2014-09-08 (+364d) |  |  |  | was named Summer 2014 DEWi UAT; constraint none → start no earlier than 2014-09-02 |
| 89 | Summer 2015 xslt rework | 2013-09-19 → 2014-09-18 (+364d) | 2013-09-24 → 2014-09-23 (+364d) |  |  |  | was named Summer 2014 xslt rework; constraint finish no earlier than 2011-09-21 → start no earlier than 2014-09-18 |

| ID | Task | Start | Finish | Duration | Total float | Predecessors | Other |
| --- | --- | --- | --- | --- | --- | --- | --- |
| 90 | Summer 2015 xslt rework UAT | 2013-09-25 → 2014-09-24 (+364d) | 2013-09-26 → 2014-09-25 (+364d) |  |  |  | was named Summer 2014 xslt rework UAT; constraint start no earlier than 2008-12-11 → start no earlier than 2014-09-24 |
| 91 | Summer 2015 DEWi rework | 2013-09-19 → 2014-09-18 (+364d) | 2013-09-25 → 2014-09-24 (+364d) |  |  |  | was named Summer 2014 DEWi rework; constraint start no earlier than 2012-09-13 → start no earlier than 2014-09-18 |
| 92 | Summer 2015 Release to test DEWi site for NDC & Attendance collections 2014 | 2013-09-26 → 2014-09-25 (+364d) | 2013-09-26 → 2014-09-25 (+364d) |  |  |  | was named Summer 2014 Release to test DEWi site for NDC & Attendance collections 2013; constraint start no earlier than 2009-10-02 → start no earlier than 2014-09-25 |
| 93 | Summer 2015 xslt final fileset release | 2013-09-27 → 2014-09-26 (+364d) | 2013-09-27 → 2014-09-26 (+364d) |  |  |  | was named Summer 2014 xslt final fileset release; constraint start no earlier than 2012-09-26 → start no earlier than 2014-09-26 |
| 94 | Summer 2015 DEWi UAT on test site | 2013-09-30 → 2014-09-29 (+364d) | 2013-10-02 → 2014-10-01 (+364d) |  |  |  | was named Summer 2014 DEWi UAT on test site; constraint none → start no earlier than 2014-09-29 |
| 95 | Summer 2015 Release to supplier test DEWi site for NDC & Attendance collections 2014 | 2013-10-03 → 2014-10-02 (+364d) | 2013-10-03 → 2014-10-02 (+364d) |  |  |  | was named Summer 2014 Release to supplier test DEWi site for NDC & Attendance collections 2013; constraint start no earlier than 2011-10-03 → start no earlier than 2014-10-02 |
| 96 | Summer 2015 Release to live DEWi site for NDC & Attendance collections 2014 | 2014-05-02 → 2015-05-01 (+364d) | 2014-05-02 → 2015-05-01 (+364d) |  |  |  | was named Summer 2014 Release to live DEWi site for NDC & Attendance collections 2013; constraint start no earlier than 2014-05-02 → start no earlier than 2015-05-01 |
| 98 | **Summer SDF meeting** | 2013-06-07 → 2014-06-04 (+362d) | 2013-07-01 → 2014-06-26 (+360d) |  | 219d → 221d |  |  |
| 99 | Software Development Forum meeting | 2013-06-07 → 2014-06-04 (+362d) | 2013-06-07 → 2014-06-04 (+362d) |  | 219d → 221d |  | constraint start no earlier than 2013-06-07 → start no earlier than 2014-06-04 |
| 100 | Specification review period | 2013-06-10 → 2014-06-05 (+360d) | 2013-07-01 → 2014-06-26 (+360d) |  | 219d → 221d |  | was named Spec review period; constraint start no earlier than 2009-10-07 → start no earlier than 2014-06-05 |
| 101 | **Develop NDC 2015** | 2013-05-31 → 2014-05-30 (+364d) | 2013-10-01 → 2014-10-01 (+365d) | 88d → 89d | 153d → 152d |  | was named Develop NDC 2014 |
| 102 | **Specification** | 2013-05-31 → 2014-05-30 (+364d) | 2013-06-25 → 2014-06-26 (+366d) | 18d → 20d | 223d → 221d |  |  |
| 103 | Draft specification release | 2013-05-31 → 2014-05-30 (+364d) | 2013-05-31 → 2014-05-30 (+364d) |  |  |  | constraint start no earlier than 2013-05-31 → start no earlier than 2014-05-30 |
| 104 | Supplier review period | 2013-06-03 → 2014-06-04 (+366d) | 2013-06-24 → 2014-06-25 (+366d) |  | 223d → 221d |  | constraint start no earlier than 2011-06-08 → start no earlier than 2014-06-04 |
| 105 | Version 1 specification release | 2013-06-25 → 2014-06-26 (+366d) | 2013-06-25 → 2014-06-26 (+366d) |  | 223d → 221d |  | constraint start no earlier than 2012-06-27 → start no earlier than 2014-06-24 |
| 106 | **xslt development** | 2013-09-03 → 2014-09-02 (+364d) | 2013-09-27 → 2014-09-26 (+364d) |  |  |  |  |
| 107 | Draft fileset release | 2013-09-03 → 2014-09-02 (+364d) | 2013-09-03 → 2014-09-02 (+364d) |  |  |  | constraint start no earlier than 2013-09-03 → start no earlier than 2014-09-02 |
| 108 | Supplier review period | 2013-09-04 → 2014-09-03 (+364d) | 2013-09-18 → 2014-09-17 (+364d) |  | 161d → 155d |  | constraint start no earlier than 2008-09-16 → start no earlier than 2014-09-03 |
| 109 | Final fileset release | 2013-09-19 → 2014-09-18 (+364d) | 2013-09-27 → 2014-09-26 (+364d) |  |  |  | constraint finish no earlier than 2013-09-27 → start no earlier than 2014-09-18 |
| 110 | **DEWi developments** | 2013-10-01 → 2014-10-01 (+365d) | 2013-10-01 → 2014-10-01 (+365d) |  | 153d → 152d |  |  |
| 111 | Release to supplier test DEWi sites for Attendance & NDC 2014 | 2013-10-01 → 2014-10-01 (+365d) | 2013-10-01 → 2014-10-01 (+365d) |  | 153d → 152d |  | constraint start no earlier than 2013-10-01 → start no earlier than 2014-10-01 |
| 113 | DEWI user audit | 2013-09-03 → 2014-09-01 (+363d) | 2013-09-30 → 2014-09-26 (+361d) |  | 154d → 155d |  | constraint start no earlier than 2013-09-03 → start no earlier than 2014-09-01 |
| 116 | **Autumn SDF meetings** | 2013-10-09 → 2014-10-08 (+364d) | 2013-11-06 → 2014-11-11 (+370d) | 21d → 25d | 127d → 123d |  |  |
| 117 | Software Development Forum meeting | 2013-10-09 → 2014-10-08 (+364d) | 2013-10-09 → 2014-10-08 (+364d) |  | 130d → 146d |  | constraint start no earlier than 2013-10-09 → start no earlier than 2014-10-08 |
| 118 | Software Development Forum meeting | 2013-11-06 → 2014-11-11 (+370d) | 2013-11-06 → 2014-11-11 (+370d) |  | 127d → 123d | Spec review period → 117 | constraint start no earlier than 2013-11-06 → start no earlier than 2014-11-11 |
| 121 | **Develop Post-16 September 2015** | 2013-10-04 → 2014-03-18 (+165d) | 2014-04-11 → 2014-09-09 (+151d) | 136d → 126d | 15d → 168d |  | was named Develop Post-16 September PLASC 2014 |
| 122 | **Specification** | 2013-10-04 → 2014-03-18 (+165d) | 2013-11-01 → 2014-04-09 (+159d) | 21d → 17d | 130d → 277d |  |  |
| 123 | Draft specification release | 2013-10-04 → 2014-03-18 (+165d) | 2013-10-04 → 2014-03-18 (+165d) |  | 134d → 277d |  | constraint start no earlier than 2013-10-04 → start no earlier than 2014-03-18 |
| 124 | Supplier review period | 2013-10-07 → 2014-03-19 (+163d) | 2013-10-28 → 2014-04-09 (+163d) |  | 134d → 277d |  | constraint start no earlier than 2011-10-12 → start no earlier than 2014-03-05 |
| 125 | Version 1 specification release | 2013-11-01 → 2014-03-31 (+150d) | 2013-11-01 → 2014-03-31 (+150d) |  | 130d → 284d |  | constraint start no earlier than 2013-11-01 → start no earlier than 2014-03-31 |
| 126 | **xslt development** | 2013-11-20 → 2014-04-08 (+139d) | 2014-04-11 → 2014-08-14 (+125d) | 103d → 93d | 15d → 186d |  |  |
| 127 | Draft fileset release | 2013-11-20 → 2014-04-08 (+139d) | 2013-11-20 → 2014-04-08 (+139d) |  | 105d → 266d |  | constraint start no earlier than 2013-11-20 → start no earlier than 2014-04-08 |
| 128 | Supplier review period | 2013-11-21 → 2014-04-09 (+139d) | 2013-12-05 → 2014-04-23 (+139d) |  | 105d → 266d |  | constraint none → start no earlier than 2014-04-09 |
| 129 | Final fileset release | 2013-12-13 → 2014-04-24 (+132d) | 2013-12-13 → 2014-04-24 (+132d) |  | 100d → 266d |  | constraint start no earlier than 2013-12-13 → start no earlier than 2014-03-31 |
| 130 | Update of fileset release with 15/16 look-ups | 2014-04-11 → 2014-08-14 (+125d) | 2014-04-11 → 2014-08-14 (+125d) |  | 15d → 186d |  | was named Update of fileset release with 14/15 look-ups; constraint start no earlier than 2014-04-11 → start no earlier than 2014-08-14 |
| 131 | **DEWi developments** | 2013-12-13 → 2014-04-24 (+132d) | 2014-04-04 → 2014-09-09 (+158d) | 81d → 99d | 20d → 168d |  |  |
| 132 | Release to supplier test DEWi sites for Post-16 September 2015 | 2013-12-13 → 2014-04-24 (+132d) | 2013-12-13 → 2014-04-24 (+132d) |  | 100d → 266d |  | was named Release to supplier test DEWi sites for Post-16 September PLASC 2014; constraint start no earlier than 2013-12-13 → start no earlier than 2014-04-24 |
| 133 | Release update with look-ups to supplier test DEWi site Post-16 September 2015 | 2014-04-04 → 2014-09-09 (+158d) | 2014-04-04 → 2014-09-09 (+158d) |  | 20d → 168d |  | was named Release update with look-ups to supplier test DEWi site Post-16 September PLASC 2014; constraint start no earlier than 2014-04-04 → start no earlier than 2014-09-09 |
| 135 | **Post-16 2015 xslt and DEWi development** | 2013-11-01 → 2014-03-18 (+137d) | 2014-04-10 → 2014-09-16 (+159d) | 115d → 131d | 16d → 163d |  | was named Post-16 Sept 2014 xslt and DEWi development |
| 136 | Post-16 2015 xslt and DEWi development | 2013-11-01 → 2014-03-18 (+137d) | 2013-11-14 → 2014-03-31 (+137d) |  | 92d → 255d |  | was named Sept 2014 xslt and DEWi development; constraint start no earlier than 2013-11-01 → start no earlier than 2014-03-18 |
| 137 | Post-16 2015 xslt UAT | 2013-11-15 → 2014-04-01 (+137d) | 2013-11-19 → 2014-04-03 (+135d) |  | 92d → 255d |  | was named Sept 2014 xslt UAT; constraint start no earlier than 2009-11-16 → start no earlier than 2014-03-17 |
| 138 | Post-16 2015 xslt draft fileset release | 2013-11-20 → 2014-04-04 (+135d) | 2013-11-20 → 2014-04-04 (+135d) |  | 92d → 255d |  | was named Sept 2014 xslt draft fileset release; constraint start no earlier than 2009-11-23 → start no earlier than 2014-03-20 |
| 139 | Post-16 2015 xslt supplier review period | 2013-11-21 → 2014-04-07 (+137d) | 2013-12-05 → 2014-04-21 (+137d) |  | 92d → 255d |  | was named Sept 2014 xslt supplier review period; constraint none → start no earlier than 2014-03-25 |
| 140 | Post-16 2015 DEWi UAT | 2013-11-20 → 2014-04-04 (+135d) | 2013-11-22 → 2014-04-08 (+137d) |  | 105d → 268d |  | was named September 2014 DEWi UAT; constraint none → start no earlier than 2014-03-20 |
| 141 | Post-16 2015 xslt rework | 2013-12-06 → 2014-04-22 (+137d) | 2013-12-10 → 2014-04-24 (+135d) |  | 92d → 255d |  | was named Sept 2014 xslt rework; constraint none → start no earlier than 2014-04-09 |
| 142 | Post-16 2015 xslt rework UAT | 2013-12-11 → 2014-04-25 (+135d) | 2013-12-12 → 2014-04-28 (+137d) |  | 92d → 255d |  | was named Sept 2014 xslt rework UAT; constraint none → start no earlier than 2014-04-16 |
| 143 | Post-16 2015 DEWi rework | 2013-12-06 → 2014-04-22 (+137d) | 2013-12-12 → 2014-04-28 (+137d) |  | 96d → 259d |  | was named September 2014 DEWi rework; constraint none → start no earlier than 2014-04-09 |
| 144 | Post-16 2015 Release to test DEWi site | 2013-12-13 → 2014-04-29 (+137d) | 2013-12-13 → 2014-04-29 (+137d) |  | 96d → 259d |  | was named September 2014 Release to test DEWi site; constraint none → start no earlier than 2014-04-18 |
| 145 | Post-16 2015 xslt final fileset release | 2013-12-13 → 2014-04-29 (+137d) | 2013-12-13 → 2014-04-29 (+137d) |  | 92d → 255d |  | was named Sept 2014 xslt final fileset release; constraint start no earlier than 2011-12-12 → start no earlier than 2014-04-18 |
| 146 | Post-16 2015 DEWi UAT on test site | 2013-12-16 → 2014-04-30 (+135d) | 2013-12-18 → 2014-05-02 (+135d) |  | 96d → 259d |  | was named September 2014 DEWi UAT on test site; constraint none → start no earlier than 2014-04-17 |
| 147 | Post-16 2015 Release to supplier test DEWi site | 2013-12-19 → 2014-05-05 (+137d) | 2013-12-19 → 2014-05-05 (+137d) |  | 96d → 259d |  | was named September 2014 Release to supplier test DEWi site; constraint start no earlier than 2013-12-19 → start no earlier than 2014-04-22 |
| 148 | Post-16 2015 xslt and DEWi inclusion of 15/16 look-ups | 2014-04-01 → 2014-04-30 (+29d) | 2014-04-04 → 2014-05-05 (+31d) |  | 16d → 255d |  | was named Sept 2014 xslt and DEWi inclusion of 14/15 look-ups |
| 149 | Post-16 2015 xslt and DEWi UAT on 14/15 look-ups update | 2014-04-07 → 2014-09-02 (+148d) | 2014-04-09 → 2014-09-04 (+148d) |  | 16d → 170d |  | was named Sept 2014 xslt and DEWi UAT on 14/15 look-ups update; constraint none → start no earlier than 2014-09-02 |
| 150 | Post-16 2015 xslt update release | 2014-04-10 → 2014-09-12 (+155d) | 2014-04-10 → 2014-09-12 (+155d) |  | 16d → 165d |  | was named Sept 2014 xslt update release; constraint start no earlier than 2010-04-15 → start no earlier than 2014-09-12 |
| 151 | Post-16 2015 Release to live DEWi site | 2014-04-10 → 2014-09-16 (+159d) | 2014-04-10 → 2014-09-16 (+159d) |  | 16d → 163d |  | was named September 2014 Release to live DEWi site; constraint start no earlier than 2010-09-16 → start no earlier than 2014-09-16 |
| 153 | CTF14 consultation | 2013-12-03 → 2014-12-02 (+364d) | 2013-12-31 → 2014-12-30 (+364d) |  |  |  | constraint start no earlier than 2013-12-03 → start no earlier than 2014-12-02 |
| 155 | Jan PLASC & EOTAS 2015 Guidance Notes Released | 2013-12-10 → 2014-10-24 (+318d) | 2013-12-10 → 2014-10-24 (+318d) |  | 103d → 135d |  | was named Jan PLASC & EOTAS 2014 Guidance Notes Released; constraint start no earlier than 2013-12-10 → start no earlier than 2014-10-24 |
| 157 | Data removal - Post-16 September 2014 data | 2014-01-24 → 2015-01-26 (+367d) | 2014-01-24 → 2015-01-26 (+367d) |  | 70d → 69d |  | was named Data removal - Post-16 September PLASC 2013 data; constraint start no earlier than 2014-01-24 → start no earlier than 2015-01-26 |
| 159 | CTF14 draft release to suppliers | 2014-01-31 → 2015-01-30 (+364d) | 2014-02-27 → 2015-02-26 (+364d) |  |  |  | constraint start no earlier than 2014-01-31 → start no earlier than 2015-01-30 |
